# Projet GE5 Laser

Schedule from GanttProject, 2020-09-16 to 2020-12-21.
Holidays every year on 01-01, 05-01, 05-08, 07-14, 08-15, 11-01, 11-11, 12-25

## Calendars

- Project calendar: Mon-Fri working; Sat-Sun off.

## Resources

| Resource |
| --- |
| Jordan |
| Benoit |
| Rémy |

## Schedule

| ID | WBS | Task | Type | Duration | Start | Finish | Predecessors | Resources |
| --- | --- | --- | --- | --- | --- | --- | --- | --- |
| 1 | 1 | Reprise codes existants |  | 4d | 2020-09-16 | 2020-09-21 |  | Benoit |
| 2 | 2 | **Implémentation VHDL** |  | 54d | 2020-09-21 | 2020-12-04 |  | Benoit |
| 3 | 2.1 | Protocole d'essai |  | 15d | 2020-09-21 | 2020-10-09 |  | Benoit |
| 4 | 2.2 | Com HPS & Periphériques |  | 9d | 2020-10-12 | 2020-10-22 | 3 | Benoit |
| 5 | 2.3 | Polynôme VHDL |  | 12d | 2020-10-23 | 2020-11-09 | 4 | Benoit |
| 6 | 2.4 | RST VHDL |  | 18d | 2020-11-10 | 2020-12-04 | 5 | Benoit |
| 7 | 3 | Appropriation du projet |  | 6d | 2020-09-16 | 2020-09-23 |  | Jordan; Rémy |
| 8 | 4 | **Automatique** |  | 47d | 2020-09-25 | 2020-12-01 | 7 | Jordan |
| 9 | 4.1 | Théorie SCILAB |  | 16d | 2020-09-25 | 2020-10-16 |  | Jordan |
| 10 | 4.2 | ID Moteur |  | 16d | 2020-10-19 | 2020-11-09 | 9 | Jordan |
| 11 | 4.3 | RST Théorique |  | 15d | 2020-11-10 | 2020-12-01 | 10 | Jordan |
| 12 | 5 | **Implémentation C** |  | 49d | 2020-09-25 | 2020-12-03 | 7 | Rémy |
| 13 | 5.1 | Choix µP |  | 6d | 2020-09-25 | 2020-10-02 |  | Rémy |
| 14 | 5.2 | Choix carte de dev + Interface |  | 13d | 2020-10-05 | 2020-10-21 | 13 | Rémy |
| 15 | 5.3 | Chaîne de dev et contrôle moteur |  | 6d | 2020-10-22 | 2020-10-29 | 14 | Rémy |
| 16 | 5.4 | RST Soft |  | 24d | 2020-10-30 | 2020-12-03 | 15 | Rémy |
| 17 | 6 | TESTS |  | 11d | 2020-12-07 | 2020-12-21 | 2, 8, 12 | Jordan; Benoit; Rémy |
| 18 | 7 | JALON (Tests BO) | milestone | 0d | 2020-10-16 | 2020-10-16 |  | Jordan; Benoit; Rémy |
